# 2017 Annual Report

How a schedule from MS Project changed from version to version. A marks actual dates.

## Version 1 (data date 2017-03-02, saved 2016-07-12, file 7wbs.mpp)

| ID | WBS | Task | Duration | Start | Finish | Predecessors | Complete | Total float | Constraint |
| --- | --- | --- | --- | --- | --- | --- | --- | --- | --- |
| 1 | A | **Annual Financial Report** | 150d | 2017-01-06 A | 2017-08-03 |  | 33% | 0d |  |
| 2 | A-001 | **Initial Planning** | 3d | 2017-01-06 A | 2017-01-10 A |  | 100% |  |  |
| 3 |  | Outline report articles | 3d | 2017-01-06 A | 2017-01-10 A |  | 100% |  |  |
| 4 | A-002 | **Interview Management** | 3.5d | 2017-01-09 A | 2017-01-12 A |  | 100% |  |  |
| 5 |  | President | 0.5d | 2017-01-09 A | 2017-01-09 A | 3 | 100% |  |  |
| 6 |  | Vice President | 0.5d | 2017-01-09 A | 2017-01-09 A | 5 | 100% |  |  |
| 7 |  | Marketing VP | 0.5d | 2017-01-12 A | 2017-01-12 A | 6 | 100% |  |  |
| 8 |  | Chief Financial Officer | 0.5d | 2017-01-10 A | 2017-01-10 A | 7 | 100% |  |  |
| 9 | A-003 | **Assemble Financial Reports** | 13d | 2017-01-09 A | 2017-01-26 A |  | 100% |  |  |
| 10 |  | Gather financial data | 3.38d | 2017-01-09 A | 2017-01-12 A | 3 | 100% |  |  |
| 11 |  | Format reports | 2d | 2017-01-10 A | 2017-01-11 A | 10FS-2d | 100% |  |  |
| 12 |  | Compile data reference report | 1d | 2017-01-16 A | 2017-01-16 A | 11 | 100% |  |  |
| 13 |  | Create graphics and charts | 3.12d | 2017-01-16 A | 2017-01-18 A | 12SS | 100% |  |  |
| 14 |  | Review by CFO | 5d | 2017-01-16 A | 2017-01-20 A | 13 | 100% |  |  |
| 15 |  | Edit | 2d | 2017-01-23 A | 2017-01-24 A | 14 | 100% |  |  |
| 16 |  | Final approval | 0d | 2017-01-26 A | 2017-01-26 A |  | 100% |  | start no earlier than 2017-01-26 |
| 17 | A-004 | **Write Articles** | 121d | 2017-01-26 A | 2017-07-13 |  | 25% | 0d |  |
| 18 |  | Write first draft | 3d | 2017-01-26 A | 2017-01-30 A | 16 | 100% |  |  |
| 19 |  | Management review | 6d | 2017-07-04 | 2017-07-11 | 18 |  | 0d | finish no earlier than 2017-07-11 |
| 20 |  | Edit | 3d | 2017-07-11 | 2017-07-13 | 19FS-1d |  | 0d |  |
| 21 |  | Final text approval | 0d | 2017-07-13 | 2017-07-13 | 20 |  | 0d |  |
| 22 | A-005 | **Prepare Final Materials** | 8.5d | 2017-07-14 | 2017-07-26 |  |  | 0d |  |
| 23 |  | Final layout | 3d | 2017-07-14 | 2017-07-18 | 21 |  | 0d |  |
| 24 |  | Final proof | 3d | 2017-07-19 | 2017-07-21 | 23 |  | 0d |  |
| 25 |  | Copy reports | 2.5d | 2017-07-24 | 2017-07-26 | 24 |  | 0d |  |
| 26 |  | Write cover letter | 2d | 2017-07-24 | 2017-07-26 | 25FF |  | 0d |  |
| 27 | A-006 | **Distribute Reports** | 149.88d | 2017-01-06 | 2017-08-03 |  |  | 0d |  |
| 28 |  | Order envelopes/paper stock | 1d | 2017-07-26 | 2017-07-27 | 26 |  | 0d |  |
| 29 |  | Print cover letters/envelopes | 1.62d | 2017-08-01 | 2017-08-02 | 28FS+3d |  | 0d |  |
| 30 |  | Stuff report packets | 1d | 2017-08-03 | 2017-08-03 | 29 |  | 0d |  |
| 31 |  | Report packets sent | 0d | 2017-08-03 | 2017-08-03 | 30 |  | 0d |  |
| 32 |  | Company Conference | 25.62d | 2017-01-06 | 2017-02-10 |  |  | 124.25d |  |

## Version 2 (data date 2017-09-28, saved 2016-07-02, file 1report.mpp)

Last finish 2017-08-03 → 2017-09-28 (+56d). Complete tasks 13 → 10.

Removed: 32 Company Conference

Changed:

| ID | Task | Start | Finish | Duration | Complete | Total float | Other |
| --- | --- | --- | --- | --- | --- | --- | --- |
| 1 | **Annual Financial Report** | 2017-01-06 A → 2017-08-04 A (+210d) | 2017-08-03 → 2017-09-28 (+56d) | 150d → 39.38d | 33% → 44% |  | baseline start 2013-01-04 → none; baseline finish 2013-08-01 → none |
| 2 | **Initial Planning** | 2017-01-06 A → 2017-08-04 A (+210d) | 2017-01-10 A → 2017-08-08 A (+210d) |  |  |  | baseline start 2013-01-04 → none; baseline finish 2013-01-08 → none |
| 3 | Outline report articles | 2017-01-06 A → 2017-08-04 A (+210d) | 2017-01-10 A → 2017-08-08 A (+210d) |  |  |  | baseline start 2013-01-04 → none; baseline finish 2013-01-08 → none |
| 4 | **Interview Management** | 2017-01-09 A → 2017-08-07 A (+210d) | 2017-01-12 A → 2017-08-10 A (+210d) |  |  |  | baseline start 2013-01-07 → none; baseline finish 2013-01-10 → none |
| 5 | President | 2017-01-09 A → 2017-08-07 A (+210d) | 2017-01-09 A → 2017-08-07 A (+210d) |  |  |  | baseline start 2013-01-07 → none; baseline finish 2013-01-07 → none |
| 6 | Vice President | 2017-01-09 A → 2017-08-07 A (+210d) | 2017-01-09 A → 2017-08-07 A (+210d) |  |  |  | baseline start 2013-01-07 → none; baseline finish 2013-01-07 → none |
| 7 | Marketing VP | 2017-01-12 A → 2017-08-10 A (+210d) | 2017-01-12 A → 2017-08-10 A (+210d) |  |  |  | baseline start 2013-01-10 → none; baseline finish 2013-01-10 → none |
| 8 | Chief Financial Officer | 2017-01-10 A → 2017-08-08 A (+210d) | 2017-01-10 A → 2017-08-08 A (+210d) |  |  |  | baseline start 2013-01-08 → none; baseline finish 2013-01-08 → none |
| 9 | **Assemble Financial Reports** | 2017-01-09 A → 2017-08-07 A (+210d) | 2017-01-26 A → 2017-08-24 (+210d) |  | 100% → 94% | none → 25.38d | baseline start 2013-01-07 → none; baseline finish 2013-01-24 → none |
| 10 | Gather financial data | 2017-01-09 A → 2017-08-07 A (+210d) | 2017-01-12 A → 2017-08-10 A (+210d) |  |  |  | baseline start 2013-01-07 → none; baseline finish 2013-01-10 → none |
| 11 | Format reports | 2017-01-10 A → 2017-08-08 A (+210d) | 2017-01-11 A → 2017-08-09 A (+210d) |  |  |  | baseline start 2013-01-08 → none; baseline finish 2013-01-09 → none |
| 12 | Compile data reference report | 2017-01-16 A → 2017-08-14 A (+210d) | 2017-01-16 A → 2017-08-14 A (+210d) |  |  |  | baseline start 2013-01-14 → none; baseline finish 2013-01-14 → none |
| 13 | Create graphics and charts | 2017-01-16 A → 2017-08-14 A (+210d) | 2017-01-18 A → 2017-08-16 A (+210d) |  |  |  | baseline start 2013-01-14 → none; baseline finish 2013-01-16 → none |
| 14 | Review by CFO | 2017-01-16 A → 2017-08-14 A (+210d) | 2017-01-20 A → 2017-08-18 A (+210d) |  |  |  | baseline start 2013-01-14 → none; baseline finish 2013-01-18 → none |
| 15 | Edit | 2017-01-23 A → 2017-08-21 A (+210d) | 2017-01-24 A → 2017-08-22 (+210d) |  | 100% → 50% | none → 26.38d | baseline start 2013-01-21 → none; baseline finish 2013-01-22 → none |
| 16 | Final approval | 2017-01-26 A → 2017-08-24 (+210d) | 2017-01-26 A → 2017-08-24 (+210d) |  | 100% → 0% | none → 0d | constraint start no earlier than 2017-01-26 → start no earlier than 2017-08-24; baseline start 2013-01-24 → none; baseline finish 2013-01-24 → none |
| 17 | **Write Articles** | 2017-01-26 A → 2017-08-24 (+210d) | 2017-07-13 → 2017-09-06 (+55d) | 121d → 10d | 25% → 0% |  | baseline start 2013-01-24 → none; baseline finish 2013-07-11 → none |
| 18 | Write first draft | 2017-01-26 A → 2017-08-24 (+210d) | 2017-01-30 A → 2017-08-28 (+210d) |  | 100% → 0% | none → 0d | baseline start 2013-01-24 → none; baseline finish 2013-01-28 → none |
| 19 | Management review | 2017-07-04 → 2017-08-29 (+56d) | 2017-07-11 → 2017-09-04 (+55d) | 6d → 5d |  |  | constraint finish no earlier than 2017-07-11 → as late as possible; baseline start 2013-07-02 → none; baseline finish 2013-07-09 → none |
| 20 | Edit | 2017-07-11 → 2017-09-04 (+55d) | 2017-07-13 → 2017-09-06 (+55d) |  |  |  | baseline start 2013-07-09 → none; baseline finish 2013-07-11 → none |
| 21 | Final text approval | 2017-07-13 → 2017-09-06 (+55d) | 2017-07-13 → 2017-09-06 (+55d) |  |  |  | baseline start 2013-07-11 → none; baseline finish 2013-07-11 → none |
| 22 | **Prepare Final Materials** | 2017-07-14 → 2017-09-07 (+55d) | 2017-07-26 → 2017-09-19 (+55d) |  |  |  | baseline start 2013-07-12 → none; baseline finish 2013-07-24 → none |
| 23 | Final layout | 2017-07-14 → 2017-09-07 (+55d) | 2017-07-18 → 2017-09-11 (+55d) |  |  |  | baseline start 2013-07-12 → none; baseline finish 2013-07-16 → none |
| 24 | Final proof | 2017-07-19 → 2017-09-12 (+55d) | 2017-07-21 → 2017-09-14 (+55d) |  |  |  | baseline start 2013-07-17 → none; baseline finish 2013-07-19 → none |
| 25 | Copy reports | 2017-07-24 → 2017-09-15 (+53d) | 2017-07-26 → 2017-09-19 (+55d) |  |  |  | baseline start 2013-07-22 → none; baseline finish 2013-07-24 → none |
| 26 | Write cover letter | 2017-07-24 → 2017-09-15 (+53d) | 2017-07-26 → 2017-09-19 (+55d) |  |  |  | baseline start 2013-07-22 → none; baseline finish 2013-07-24 → none |
| 27 | **Distribute Reports** | 2017-01-06 → 2017-09-19 (+256d) | 2017-08-03 → 2017-09-28 (+56d) | 149.88d → 6.88d |  |  | baseline start 2013-01-04 → none; baseline finish 2013-08-01 → none |
| 28 | Order envelopes/paper stock | 2017-07-26 → 2017-09-19 (+55d) | 2017-07-27 → 2017-09-20 (+55d) |  |  |  | baseline start 2013-07-24 → none; baseline finish 2013-07-25 → none |
| 29 | Print cover letters/envelopes | 2017-08-01 → 2017-09-25 (+55d) | 2017-08-02 → 2017-09-27 (+56d) | 1.62d → 2d |  |  | baseline start 2013-07-30 → none; baseline finish 2013-07-31 → none |
| 30 | Stuff report packets | 2017-08-03 → 2017-09-27 (+55d) | 2017-08-03 → 2017-09-28 (+56d) |  |  |  | baseline start 2013-08-01 → none; baseline finish 2013-08-01 → none |
| 31 | Report packets sent | 2017-08-03 → 2017-09-28 (+56d) | 2017-08-03 → 2017-09-28 (+56d) |  |  |  | constraint none → as late as possible; baseline start 2013-08-01 → none; baseline finish 2013-08-01 → none |
