# Office Remodel

How a schedule from MS Project changed from version to version. A marks actual dates.

## Version 1 (data date 2017-03-14, saved 2016-06-27, file 1custom.mpp)

| ID | WBS | Task | Duration | Start | Finish | Predecessors | Complete | Total float | Constraint |
| --- | --- | --- | --- | --- | --- | --- | --- | --- | --- |
| 1 | 1 | **Office Workspace Remodel** | 48d | 2017-01-04 A | 2017-03-13 |  |  | 0d |  |
| 2 | 1.1 | **Space planning** | 11d | 2017-01-04 A | 2017-01-19 |  |  | 37d |  |
| 3 |  | Interview space planners | 0.8w | 2017-01-04 | 2017-01-09 |  |  | 27.5d | start no earlier than 2017-01-04 |
| 4 |  | Hire space planner | 1d | 2017-01-10 | 2017-01-10 | 3 |  | 27.5d |  |
| 5 |  | Meeting w/space planner | 3d | 2017-01-11 | 2017-01-13 | 4 |  | 27.5d |  |
| 6 |  | Finalize space plan | 3d | 2017-01-16 | 2017-01-18 | 5 |  | 37d |  |
| 7 |  | Space plan complete | 0d | 2017-01-19 A | 2017-01-19 A | 6 | 100% |  |  |
| 8 | 1.2 | **Furniture selection** | 40d | 2017-01-16 | 2017-03-13 |  |  | 0d |  |
| 9 |  | Preview furniture selections | 2.5d | 2017-01-16 | 2017-01-18 | 5 |  | 27.5d |  |
| 10 |  | Select new furniture | 2d | 2017-01-18 | 2017-01-20 | 9 |  | 27.5d |  |
| 11 |  | Order new furniture | 0.5d | 2017-01-20 | 2017-01-20 | 10 |  | 27.5d |  |
| 12 |  | Furniture delivered | 0d | 2017-03-13 | 2017-03-13 | 11FS+1.5w |  | 0d | start no earlier than 2017-03-13 |
| 13 | 1.3 | **Remodel workspace** | 14d | 2017-01-19 | 2017-02-07 |  |  | 18d |  |
| 14 |  | Hire contractor | 4d | 2017-01-19 | 2017-01-24 | 7 |  | 18d |  |
| 15 |  | Remodel workspace | 2w | 2017-01-25 | 2017-02-07 | 14 |  | 18d |  |
| 16 |  | Remodel complete | 0d | 2017-02-07 | 2017-02-07 | 15 |  | 23d |  |
| 17 | 1.4 | **New workspace** | 18d | 2017-01-19 | 2017-02-13 |  |  | 19d |  |
| 18 |  | Hire mover | 4d | 2017-01-19 | 2017-01-24 | 14SS |  | 25d |  |
| 19 |  | Pack workspace | 1d | 2017-01-25 | 2017-01-25 | 18, 14 |  | 25d |  |
| 20 |  | Move Equipment | 0.5d | 2017-01-25 | 2017-01-25 | 19FF |  | 25d |  |
| 21 |  | Remove existing furniture | 2d | 2017-01-26 | 2017-01-27 | 20 |  | 25d |  |
| 22 |  | Assemble new furniture | 2d | 2017-02-08 | 2017-02-09 | 21, 15 |  | 18d | finish no earlier than 2017-02-09 |
| 23 |  | Return equipment | 0.5d | 2017-02-09 | 2017-02-09 | 22FS-0.5d |  | 18d | finish no earlier than 2017-02-09 |
| 24 |  | Unpack workspace | 1d | 2017-02-10 | 2017-02-10 | 23 |  | 18d |  |
| 25 |  | Workspace final clean | 1d | 2017-02-13 | 2017-02-13 | 24 |  | 18d |  |
| 26 |  | Workspace remodel complete | 0d | 2017-02-14 | 2017-02-14 | 17 |  | 19d | start no earlier than 2017-02-14 |

## Version 2 (saved 2016-06-27, file 1view.mpp)

Last finish stays 2017-03-13. Complete tasks 1 → 5.

Changed:

| ID | Task | Start | Finish | Duration | Complete | Total float | Other |
| --- | --- | --- | --- | --- | --- | --- | --- |
| 1 | **Office Workspace Remodel** |  |  |  | 0% → 42% |  | baseline start 2003-06-04 → 2008-01-02; baseline finish 2003-07-17 → 2008-03-10 |
| 2 | **Space planning** |  | 2017-01-19 → 2017-01-20 (+1d) | 11d → 12d | 0% → 91% | 37d → 36d | baseline start 2003-06-04 → 2008-01-02; baseline finish 2003-06-19 → 2008-01-16 |
| 3 | Interview space planners | 2017-01-04 A | 2017-01-09 A |  | 0% → 100% | 27.5d → none | baseline start 2005-06-01 → 2008-01-02; baseline finish 2005-06-05 → 2008-01-07 |
| 4 | Hire space planner | 2017-01-10 A | 2017-01-10 A |  | 0% → 100% | 27.5d → none | baseline start 2005-06-08 → 2008-01-08; baseline finish 2005-06-08 → 2008-01-08 |
| 5 | Meeting w/space planner | 2017-01-11 A | 2017-01-13 A | 3d → 2.5d | 0% → 100% | 27.5d → none | baseline start 2005-06-09 → 2008-01-09; baseline finish 2005-06-11 → 2008-01-11 |
| 6 | Finalize space plan | 2017-01-16 A | 2017-01-18 → 2017-01-19 (+1d) | 3d → 4d | 0% → 75% | 37d → 36d | baseline start 2005-06-12 → 2008-01-14; baseline finish 2005-06-16 → 2008-01-16 |
| 7 | Space plan complete | 2017-01-19 A → 2017-01-20 A (+1d) | 2017-01-19 A → 2017-01-20 A (+1d) |  |  |  | baseline start 2005-06-16 → 2008-01-16; baseline finish 2005-06-16 → 2008-01-16 |
| 8 | **Furniture selection** | 2017-01-16 A |  |  | 0% → 85% |  | baseline start 2003-06-15 → 2008-01-14; baseline finish 2003-07-02 → 2008-03-10 |
| 9 | Preview furniture selections | 2017-01-16 A | 2017-01-18 A |  | 0% → 100% | 27.5d → none | baseline start 2005-06-12 → 2008-01-14; baseline finish 2005-06-15 → 2008-01-16 |
| 10 | Select new furniture | 2017-01-18 A |  |  | 0% → 75% | 27.5d → 0.38d | baseline start 2005-06-16 → 2008-01-16; baseline finish 2005-06-17 → 2008-01-18 |
| 11 | Order new furniture | 2017-01-20 A | 2017-01-20 → 2017-01-23 (+3d) | 0.5d → 0.62d | 0% → 60% | 27.5d → 27.38d | baseline start 2005-06-17 → 2008-01-18; baseline finish 2005-06-17 → 2008-01-18 |
| 12 | Furniture delivered |  |  |  |  |  | baseline start 2005-06-29 → 2008-03-10; baseline finish 2005-06-29 → 2008-03-10 |
| 13 | **Remodel workspace** | 2017-01-19 A |  |  | 0% → 21% | 18d → 23d | baseline start 2003-06-20 → 2008-01-17; baseline finish 2003-07-09 → 2008-02-05 |
| 14 | Hire contractor | 2017-01-19 A |  |  | 0% → 75% |  | baseline start 2005-06-17 → 2008-01-17; baseline finish 2005-06-22 → 2008-01-22 |
| 15 | Remodel workspace |  |  |  |  |  | baseline start 2005-06-23 → 2008-01-23; baseline finish 2005-07-06 → 2008-02-05 |
| 16 | Remodel complete |  |  |  |  |  | baseline start 2005-07-06 → 2008-02-05; baseline finish 2005-07-06 → 2008-02-05 |
| 17 | **New workspace** |  |  |  |  |  | baseline start 2003-06-20 → 2008-01-17; baseline finish 2003-07-17 → 2008-02-11 |
| 18 | Hire mover |  |  |  |  |  | baseline start 2005-06-17 → 2008-01-17; baseline finish 2005-06-22 → 2008-01-22 |
| 19 | Pack workspace |  |  |  |  |  | baseline start 2005-06-23 → 2008-01-23; baseline finish 2005-06-23 → 2008-01-23 |
| 20 | Move Equipment |  |  |  |  |  | baseline start 2005-06-23 → 2008-01-23; baseline finish 2005-06-23 → 2008-01-23 |
| 21 | Remove existing furniture |  |  |  |  |  | baseline start 2005-07-03 → 2008-01-24; baseline finish 2005-07-03 → 2008-01-25 |
| 22 | Assemble new furniture |  |  |  |  |  | baseline start 2005-07-07 → 2008-02-06; baseline finish 2005-07-08 → 2008-02-07 |
| 23 | Return equipment |  |  |  |  |  | baseline start 2005-07-08 → 2008-02-07; baseline finish 2005-07-09 → 2008-02-07 |
| 24 | Unpack workspace |  |  |  |  |  | baseline start 2005-07-09 → 2008-02-08; baseline finish 2005-07-10 → 2008-02-08 |
| 25 | Workspace final clean |  |  |  |  |  | baseline start 2005-07-10 → 2008-02-11; baseline finish 2005-07-14 → 2008-02-11 |
| 26 | Workspace remodel complete |  |  |  |  |  | baseline start 2005-07-14 → 2008-02-11; baseline finish 2005-07-14 → 2008-02-11 |

## Version 3 (data date 2017-01-23, saved 2016-06-27, file 3visualreport.mpp)

Last finish 2017-03-13 → 2017-07-20 (+129d). Complete tasks 5 → 6.

Removed: 7 Space plan complete

Changed:

| ID | Task | Start | Finish | Duration | Complete | Total float | Predecessors | Other |
| --- | --- | --- | --- | --- | --- | --- | --- | --- |
| 1 | **Office Workspace Remodel** |  | 2017-03-13 → 2017-07-20 (+129d) | 48d → 141d | 42% → 51% |  |  | baseline start 2008-01-02 → 2013-01-02; baseline finish 2008-03-10 → 2013-07-18 |
| 2 | **Space planning** |  | 2017-01-20 → 2017-01-19 A (-1d) |  | 91% → 100% | 36d → none |  | baseline start 2008-01-02 → 2013-01-02; baseline finish 2008-01-16 → 2013-01-17 |
| 3 | Interview space planners |  |  |  |  |  |  | baseline start 2008-01-02 → 2013-01-02; baseline finish 2008-01-07 → 2013-01-07 |
| 4 | Hire space planner |  |  |  |  |  |  | baseline start 2008-01-08 → 2013-01-08; baseline finish 2008-01-08 → 2013-01-08 |
| 5 | Meeting w/space planner |  |  |  |  |  |  | baseline start 2008-01-09 → 2013-01-09; baseline finish 2008-01-11 → 2013-01-11 |
| 6 | Finalize space plan |  | 2017-01-19 A |  | 75% → 100% | 36d → none |  | baseline start 2008-01-14 → 2013-01-14; baseline finish 2008-01-16 → 2013-01-17 |
| 7 | **Furniture selection** |  |  |  | 85% → 83% | 0d → 93d |  | baseline start 2008-01-14 → 2013-01-14; baseline finish 2008-03-10 → 2013-03-11 |
| 8 | Preview furniture selections |  |  |  |  |  | 5 → 6FS-2d | baseline start 2008-01-14 → 2013-01-14; baseline finish 2008-01-16 → 2013-01-16 |
| 9 | Select new furniture |  | 2017-01-20 A |  | 75% → 100% | 0.38d → none |  | baseline start 2008-01-16 → 2013-01-16; baseline finish 2008-01-18 → 2013-01-18 |
| 10 | Order new furniture |  |  | 0.62d → 1.38d | 60% → 27% | 27.38d → 119.62d |  | baseline start 2008-01-18 → 2013-01-18; baseline finish 2008-01-18 → 2013-01-21 |
| 11 | Furniture delivered |  |  |  |  | 0d → 93d |  | baseline start 2008-03-10 → 2013-03-11; baseline finish 2008-03-10 → 2013-03-11 |
| 12 | **Remodel workspace** |  |  | 14d → 13.5d | 21% → 22% | 23d → 116.5d |  | baseline start 2008-01-17 → 2013-01-17; baseline finish 2008-02-05 → 2013-02-05 |
| 13 | Hire contractor |  |  | 4d → 3.5d | 75% → 86% | 18d → 1d | Space plan complete → none | baseline start 2008-01-17 → 2013-01-17; baseline finish 2008-01-22 → 2013-01-22 |
| 14 | Remodel workspace | 2017-01-25 → 2017-01-24 (-1d) |  |  |  | 18d → 112d |  | baseline start 2008-01-23 → 2013-01-22; baseline finish 2008-02-05 → 2013-02-05 |
| 15 | Remodel complete |  |  |  |  | 23d → 116.5d |  | baseline start 2008-02-05 → 2013-02-05; baseline finish 2008-02-05 → 2013-02-05 |
| 16 | **New workspace** | 2017-01-19 A | 2017-02-13 → 2017-07-19 (+156d) | 18d → 129.5d | 0% → 23% | 19d → 0.5d |  | baseline start 2008-01-17 → 2013-01-17; baseline finish 2008-02-11 → 2013-07-17 |
| 17 | Hire mover | 2017-01-19 A |  |  | 0% → 50% | 25d → 0.5d |  | baseline start 2008-01-17 → 2013-01-17; baseline finish 2008-01-22 → 2013-01-22 |
| 18 | Pack workspace | 2017-01-25 A |  |  | 0% → 50% | 25d → 118.5d |  | baseline start 2008-01-23 → 2013-01-23; baseline finish 2008-01-23 → 2013-01-23 |
| 19 | Move Equipment | 2017-01-25 A | 2017-01-25 → 2017-01-26 (+1d) | 0.5d → 1d | 0% → 50% | 25d → 118d |  | baseline start 2008-01-23 → 2013-01-23; baseline finish 2008-01-23 → 2013-01-24 |
| 20 | Remove existing furniture |  | 2017-01-27 → 2017-01-30 (+3d) |  |  | 25d → 118d |  | baseline start 2008-01-24 → 2013-01-24; baseline finish 2008-01-25 → 2013-01-28 |
| 21 | Assemble new furniture | 2017-02-08 → 2017-07-13 (+155d) | 2017-02-09 → 2017-07-14 (+155d) |  |  | 18d → 0.5d |  | constraint finish no earlier than 2017-02-09 → finish no earlier than 2017-07-14; baseline start 2008-02-06 → 2013-07-11; baseline finish 2008-02-07 → 2013-07-12 |
| 22 | Return equipment | 2017-02-09 → 2017-07-14 (+155d) | 2017-02-09 → 2017-07-14 (+155d) |  |  | 18d → 0.5d |  | constraint finish no earlier than 2017-02-09 → finish no earlier than 2017-07-14; baseline start 2008-02-07 → 2013-07-12; baseline finish 2008-02-07 → 2013-07-12 |
| 23 | Unpack workspace | 2017-02-10 → 2017-07-17 (+157d) | 2017-02-10 → 2017-07-17 (+157d) |  |  | 18d → 0.5d |  | baseline start 2008-02-08 → 2013-07-15; baseline finish 2008-02-08 → 2013-07-15 |
| 24 | Workspace final clean | 2017-02-13 → 2017-07-18 (+155d) | 2017-02-13 → 2017-07-19 (+156d) | 1d → 1.5d |  | 18d → 0.5d |  | baseline start 2008-02-11 → 2013-07-16; baseline finish 2008-02-11 → 2013-07-17 |
| 25 | Workspace remodel complete | 2017-02-14 → 2017-07-20 (+156d) | 2017-02-14 → 2017-07-20 (+156d) |  |  | 19d → 0d |  | constraint start no earlier than 2017-02-14 → start no earlier than 2017-07-20; baseline start 2008-02-11 → 2013-07-18; baseline finish 2008-02-11 → 2013-07-18 |

## Version 4 (data date 2013-01-22, saved 2016-06-27, file 4export.mpp)

Last finish 2017-07-20 → 2013-03-11 (-1592d). Complete tasks 6 → 8.

Changed:

| ID | Task | Start | Finish | Duration | Complete | Total float | Predecessors | Other |
| --- | --- | --- | --- | --- | --- | --- | --- | --- |
| 1 | **Office Workspace Remodel** | 2017-01-04 A → 2013-01-02 A (-1463d) | 2017-07-20 → 2013-03-11 (-1592d) | 141d → 48d | 51% → 76% |  |  | baseline start 2013-01-02 → 2011-01-05; baseline finish 2013-07-18 → 2011-07-21 |
| 2 | **Space planning** | 2017-01-04 A → 2013-01-02 A (-1463d) | 2017-01-19 A → 2013-01-17 (-1463d) |  | 100% → 91% | none → 36d |  | baseline start 2013-01-02 → 2011-01-05; baseline finish 2013-01-17 → 2011-01-20 |
| 3 | Interview space planners | 2017-01-04 A → 2013-01-02 A (-1463d) | 2017-01-09 A → 2013-01-07 A (-1463d) |  |  |  |  | constraint start no earlier than 2017-01-04 → start no earlier than 2013-01-02; baseline start 2013-01-02 → 2011-01-05; baseline finish 2013-01-07 → 2011-01-10 |
| 4 | Hire space planner | 2017-01-10 A → 2013-01-08 A (-1463d) | 2017-01-10 A → 2013-01-08 A (-1463d) |  |  |  |  | baseline start 2013-01-08 → 2011-01-11; baseline finish 2013-01-08 → 2011-01-11 |
| 5 | Meeting w/space planner | 2017-01-11 A → 2013-01-09 A (-1463d) | 2017-01-13 A → 2013-01-11 A (-1463d) |  |  |  |  | baseline start 2013-01-09 → 2011-01-12; baseline finish 2013-01-11 → 2011-01-14 |
| 6 | Finalize space plan | 2017-01-16 A → 2013-01-14 A (-1463d) | 2017-01-19 A → 2013-01-17 (-1463d) |  | 100% → 75% | none → 36d |  | baseline start 2013-01-14 → 2011-01-17; baseline finish 2013-01-17 → 2011-01-20 |
| 7 | **Furniture selection** | 2017-01-16 A → 2013-01-14 A (-1463d) | 2017-03-13 → 2013-03-11 (-1463d) |  | 83% → 94% | 93d → 0d |  | baseline start 2013-01-14 → 2011-01-17; baseline finish 2013-03-11 → 2011-03-14 |
| 8 | Preview furniture selections | 2017-01-16 A → 2013-01-14 A (-1463d) | 2017-01-18 A → 2013-01-16 A (-1463d) |  |  |  | 6FS-2d → 5 | baseline start 2013-01-14 → 2011-01-17; baseline finish 2013-01-16 → 2011-01-19 |
| 9 | Select new furniture | 2017-01-18 A → 2013-01-16 A (-1463d) | 2017-01-20 A → 2013-01-18 A (-1463d) |  |  |  |  | baseline start 2013-01-16 → 2011-01-19; baseline finish 2013-01-18 → 2011-01-21 |
| 10 | Order new furniture | 2017-01-20 A → 2013-01-18 A (-1463d) | 2017-01-23 → 2013-01-21 (-1463d) |  | 27% → 73% | 119.62d → 26.62d |  | baseline start 2013-01-18 → 2011-01-21; baseline finish 2013-01-21 → 2011-01-24 |
| 11 | Furniture delivered | 2017-03-13 → 2013-03-11 (-1463d) | 2017-03-13 → 2013-03-11 (-1463d) |  |  | 93d → 0d |  | constraint start no earlier than 2017-03-13 → start no earlier than 2013-03-11; baseline start 2013-03-11 → 2011-03-14; baseline finish 2013-03-11 → 2011-03-14 |
| 12 | **Remodel workspace** | 2017-01-19 A → 2013-01-17 A (-1463d) | 2017-02-07 → 2013-02-05 (-1463d) |  | 22% → 77% | 116.5d → 23.5d |  | baseline start 2013-01-17 → 2011-01-20; baseline finish 2013-02-05 → 2011-02-08 |
| 13 | Hire contractor | 2017-01-19 A → 2013-01-17 A (-1463d) | 2017-01-24 → 2013-01-23 (-1462d) | 3.5d → 4.25d | 86% → 82% | 1d → 6.75d |  | baseline start 2013-01-17 → 2011-01-20; baseline finish 2013-01-22 → 2011-01-26 |
| 14 | Remodel workspace | 2017-01-24 → 2013-01-22 A (-1463d) | 2017-02-07 → 2013-02-05 (-1463d) |  | 0% → 75% | 112d → 18.5d |  | baseline start 2013-01-22 → 2011-01-25; baseline finish 2013-02-05 → 2011-02-08 |
| 15 | Remodel complete | 2017-02-07 → 2013-02-05 (-1463d) | 2017-02-07 → 2013-02-05 (-1463d) |  |  | 116.5d → 23.5d |  | baseline start 2013-02-05 → 2011-02-08; baseline finish 2013-02-05 → 2011-02-08 |
| 16 | **New workspace** | 2017-01-19 A → 2013-01-17 A (-1463d) | 2017-07-19 → 2013-02-12 (-1618d) | 129.5d → 18.5d | 23% → 54% | 0.5d → 18.5d |  | baseline start 2013-01-17 → 2011-01-20; baseline finish 2013-07-17 → 2011-07-20 |
| 17 | Hire mover | 2017-01-19 A → 2013-01-17 A (-1463d) | 2017-01-24 → 2013-01-22 (-1463d) |  | 50% → 75% | 0.5d → 33d |  | baseline start 2013-01-17 → 2011-01-20; baseline finish 2013-01-22 → 2011-01-25 |
| 18 | Pack workspace | 2017-01-25 A → 2013-01-23 A (-1463d) | 2017-01-25 → 2013-01-23 A (-1463d) |  | 50% → 100% | 118.5d → none |  | baseline start 2013-01-23 → 2011-01-26; baseline finish 2013-01-23 → 2011-01-26 |
| 19 | Move Equipment | 2017-01-25 A → 2013-01-23 A (-1463d) | 2017-01-26 → 2013-01-24 A (-1463d) |  | 50% → 100% | 118d → none |  | baseline start 2013-01-23 → 2011-01-26; baseline finish 2013-01-24 → 2011-01-27 |
| 20 | Remove existing furniture | 2017-01-26 → 2013-01-24 A (-1463d) | 2017-01-30 → 2013-01-28 A (-1463d) |  | 0% → 100% | 118d → none |  | baseline start 2013-01-24 → 2011-01-27; baseline finish 2013-01-28 → 2011-01-31 |
| 21 | Assemble new furniture | 2017-07-13 → 2013-02-06 (-1618d) | 2017-07-14 → 2013-02-07 (-1618d) |  |  | 0.5d → 18d |  | constraint finish no earlier than 2017-07-14 → finish no earlier than 2013-02-07; baseline start 2013-07-11 → 2011-07-14; baseline finish 2013-07-12 → 2011-07-15 |
| 22 | Return equipment | 2017-07-14 → 2013-02-07 (-1618d) | 2017-07-14 → 2013-02-07 (-1618d) |  |  | 0.5d → 18d |  | constraint finish no earlier than 2017-07-14 → finish no earlier than 2013-02-07; baseline start 2013-07-12 → 2011-07-15; baseline finish 2013-07-12 → 2011-07-15 |
| 23 | Unpack workspace | 2017-07-17 → 2013-02-08 (-1620d) | 2017-07-17 → 2013-02-08 (-1620d) |  |  | 0.5d → 18d |  | baseline start 2013-07-15 → 2011-07-18; baseline finish 2013-07-15 → 2011-07-18 |
| 24 | Workspace final clean | 2017-07-18 → 2013-02-11 (-1618d) | 2017-07-19 → 2013-02-12 (-1618d) |  |  | 0.5d → 18d |  | baseline start 2013-07-16 → 2011-07-19; baseline finish 2013-07-17 → 2011-07-20 |
| 25 | Workspace remodel complete | 2017-07-20 → 2013-02-12 (-1619d) | 2017-07-20 → 2013-02-12 (-1619d) |  |  | 0d → 18.5d |  | constraint start no earlier than 2017-07-20 → finish no earlier than 2013-02-11; baseline start 2013-07-18 → 2011-07-21; baseline finish 2013-07-18 → 2011-07-21 |

## Version 5 (data date 2017-07-03, saved 2016-07-02, file 6share1.mpp)

Last finish 2013-03-11 → 2017-07-17 (+1589d). Complete tasks 8 → 0.

Added:

| ID | Task | Duration | Start | Finish | Predecessors |
| --- | --- | --- | --- | --- | --- |
| 7 | Space plan complete | 0d | 2017-06-19 | 2017-06-19 | 6 |

Changed:

| ID | Task | Start | Finish | Duration | Complete | Total float | Predecessors | Other |
| --- | --- | --- | --- | --- | --- | --- | --- | --- |
| 1 | **Office Workspace Remodel** | 2013-01-02 A → 2017-06-05 (+1615d) | 2013-03-11 → 2017-07-17 (+1589d) | 48d → 31d | 76% → 0% |  |  | baseline start 2011-01-05 → 2013-06-03; baseline finish 2011-07-21 → 2013-07-15 |
| 2 | **Space planning** | 2013-01-02 A → 2017-06-05 (+1615d) | 2013-01-17 → 2017-06-19 (+1614d) | 12d → 11d | 91% → 0% | 36d → 0d |  | baseline start 2011-01-05 → 2013-06-03; baseline finish 2011-01-20 → 2013-06-17 |
| 3 | Interview space planners | 2013-01-02 A → 2017-06-05 (+1615d) | 2013-01-07 A → 2017-06-08 (+1613d) |  | 100% → 0% | none → 0d |  | constraint start no earlier than 2013-01-02 → none; resources Operations Manager; Office Manager; Vice President [25%] → none; baseline start 2011-01-05 → 2013-06-03; baseline finish 2011-01-10 → 2013-06-06 |
| 4 | Hire space planner | 2013-01-08 A → 2017-06-09 (+1613d) | 2013-01-08 A → 2017-06-09 (+1613d) |  | 100% → 0% | none → 0d |  | resources Vice President; Administrative Assistant → none; baseline start 2011-01-11 → 2013-06-07; baseline finish 2011-01-11 → 2013-06-07 |
| 5 | Meeting w/space planner | 2013-01-09 A → 2017-06-12 (+1615d) | 2013-01-11 A → 2017-06-14 (+1615d) | 2.5d → 3d | 100% → 0% | none → 0d |  | resources Vice President; Administrative Assistant; Operations Manager; Space Planner → none; baseline start 2011-01-12 → 2013-06-10; baseline finish 2011-01-14 → 2013-06-12 |
| 6 | Finalize space plan | 2013-01-14 A → 2017-06-15 (+1613d) | 2013-01-17 → 2017-06-19 (+1614d) | 4d → 3d | 75% → 0% | 36d → 0d |  | resources Space Planner → none; baseline start 2011-01-17 → 2013-06-13; baseline finish 2011-01-20 → 2013-06-17 |
| 8 | **Furniture selection** | 2013-01-14 A → 2017-06-15 (+1613d) | 2013-03-11 → 2017-07-04 (+1576d) | 40d → 13d | 94% → 0% | 0d → 10d |  | baseline start 2011-01-17 → 2013-06-13; baseline finish 2011-03-14 → 2013-07-02 |
| 9 | Preview furniture selections | 2013-01-14 A → 2017-06-15 (+1613d) | 2013-01-16 A → 2017-06-19 (+1615d) |  | 100% → 0% | none → 10d |  | resources Office Manager; Operations Manager; Administrative Assistant → none; baseline start 2011-01-17 → 2013-06-13; baseline finish 2011-01-19 → 2013-06-17 |
| 10 | Select new furniture | 2013-01-16 A → 2017-06-19 (+1615d) | 2013-01-18 A → 2017-06-21 (+1615d) | 2d → 2.5d | 100% → 0% | none → 10d |  | resources Office Manager [75%]; Operations Manager → none; baseline start 2011-01-19 → 2013-06-17; baseline finish 2011-01-21 → 2013-06-19 |
| 11 | Order new furniture | 2013-01-18 A → 2017-06-22 (+1616d) | 2013-01-21 → 2017-06-22 (+1613d) | 1.38d → 0.5d | 73% → 0% | 26.62d → 10d |  | resources Administrative Assistant → none; baseline start 2011-01-21 → 2013-06-20; baseline finish 2011-01-24 → 2013-06-20 |
| 12 | Furniture delivered | 2013-03-11 → 2017-07-04 (+1576d) | 2013-03-11 → 2017-07-04 (+1576d) |  |  | 0d → 10d |  | constraint start no earlier than 2013-03-11 → start no earlier than 2017-07-04; baseline start 2011-03-14 → 2013-07-02; baseline finish 2011-03-14 → 2013-07-02 |
| 13 | **Remodel workspace** | 2013-01-17 A → 2017-06-20 (+1615d) | 2013-02-05 → 2017-07-10 (+1616d) | 13.5d → 15d | 77% → 0% | 23.5d → 0d |  | baseline start 2011-01-20 → 2013-06-18; baseline finish 2011-02-08 → 2013-07-08 |
| 14 | Hire contractor | 2013-01-17 A → 2017-06-20 (+1615d) | 2013-01-23 → 2017-06-26 (+1615d) | 4.25d → 5d | 82% → 0% | 6.75d → 0d | none → 7 | resources Vice President; Operations Manager → none; baseline start 2011-01-20 → 2013-06-18; baseline finish 2011-01-26 → 2013-06-24 |
| 15 | Remodel workspace | 2013-01-22 A → 2017-06-27 (+1617d) | 2013-02-05 → 2017-07-10 (+1616d) |  | 75% → 0% | 18.5d → 0d |  | resources Contractor [200%]; Electrician → none; baseline start 2011-01-25 → 2013-06-25; baseline finish 2011-02-08 → 2013-07-08 |
| 16 | Remodel complete | 2013-02-05 → 2017-07-10 (+1616d) | 2013-02-05 → 2017-07-10 (+1616d) |  |  | 23.5d → 5d |  | baseline start 2011-02-08 → 2013-07-08; baseline finish 2011-02-08 → 2013-07-08 |
| 17 | **New workspace** | 2013-01-17 A → 2017-06-20 (+1615d) | 2013-02-12 → 2017-07-17 (+1616d) | 18.5d → 20d | 54% → 0% | 18.5d → 0d |  | baseline start 2011-01-20 → 2013-06-18; baseline finish 2011-07-20 → 2013-07-15 |
| 18 | Hire mover | 2013-01-17 A → 2017-06-20 (+1615d) | 2013-01-22 → 2017-06-23 (+1613d) |  | 75% → 0% | 33d → 8d |  | resources Supervisor → none; baseline start 2011-01-20 → 2013-06-18; baseline finish 2011-01-25 → 2013-06-21 |
| 19 | Pack workspace | 2013-01-23 A → 2017-06-27 (+1616d) | 2013-01-23 A → 2017-06-27 (+1616d) |  | 100% → 0% | none → 7d |  | resources Administrative Assistant; Supervisor → none; baseline start 2011-01-26 → 2013-06-25; baseline finish 2011-01-26 → 2013-06-25 |
| 20 | Move Equipment | 2013-01-23 A → 2017-06-27 (+1616d) | 2013-01-24 A → 2017-06-27 (+1615d) | 1d → 0.5d | 100% → 0% | none → 7d |  | resources Mover; Operations Manager → none; baseline start 2011-01-26 → 2013-06-25; baseline finish 2011-01-27 → 2013-06-25 |
| 21 | Remove existing furniture | 2013-01-24 A → 2017-07-07 (+1625d) | 2013-01-28 A → 2017-07-10 (+1624d) |  | 100% → 0% | none → 0d |  | constraint none → as late as possible; resources Mover → none; baseline start 2011-01-27 → 2013-07-05; baseline finish 2011-01-31 → 2013-07-08 |
| 22 | Assemble new furniture | 2013-02-06 → 2017-07-11 (+1616d) | 2013-02-07 → 2017-07-12 (+1616d) |  |  | 18d → 0d |  | constraint finish no earlier than 2013-02-07 → none; resources Supervisor; Space Planner → none; baseline start 2011-07-14 → 2013-07-09; baseline finish 2011-07-15 → 2013-07-10 |
| 23 | Return equipment | 2013-02-07 → 2017-07-12 (+1616d) | 2013-02-07 → 2017-07-12 (+1616d) |  |  | 18d → 0d |  | constraint finish no earlier than 2013-02-07 → none; resources Mover; Operations Manager → none; baseline start 2011-07-15 → 2013-07-10; baseline finish 2011-07-15 → 2013-07-10 |
| 24 | Unpack workspace | 2013-02-08 → 2017-07-13 (+1616d) | 2013-02-08 → 2017-07-13 (+1616d) |  |  | 18d → 0d |  | resources Mover; Administrative Assistant → none; baseline start 2011-07-18 → 2013-07-11; baseline finish 2011-07-18 → 2013-07-11 |
| 25 | Workspace final clean | 2013-02-11 → 2017-07-14 (+1614d) | 2013-02-12 → 2017-07-17 (+1616d) | 1.5d → 2d |  | 18d → 0d |  | resources Maintenance [50%]; Mover [50%] → none; baseline start 2011-07-19 → 2013-07-12; baseline finish 2011-07-20 → 2013-07-15 |
| 26 | Workspace remodel complete | 2013-02-12 → 2017-07-17 (+1616d) | 2013-02-12 → 2017-07-17 (+1616d) |  |  | 18.5d → 0d |  | constraint finish no earlier than 2013-02-11 → finish no later than 2017-07-20; baseline start 2011-07-21 → 2013-07-15; baseline finish 2011-07-21 → 2013-07-15 |

## Version 6 (saved 2016-07-06, file 3track.mpp)

Last finish 2017-07-17 → 2017-03-13 (-126d). Complete tasks 0 → 6.

Removed: 7 Space plan complete

Changed:

| ID | Task | Start | Finish | Duration | Complete | Total float | Predecessors | Other |
| --- | --- | --- | --- | --- | --- | --- | --- | --- |
| 1 | **Office Workspace Remodel** | 2017-06-05 → 2017-01-04 A (-152d) | 2017-07-17 → 2017-03-13 (-126d) | 31d → 48d | 0% → 51% |  |  | baseline start 2013-06-03 → 2017-01-04; baseline finish 2013-07-15 → 2017-03-13 |
| 2 | **Space planning** | 2017-06-05 → 2017-01-04 A (-152d) | 2017-06-19 → 2017-01-19 A (-151d) | 11d → 12d | 0% → 100% | 0d → none |  | baseline start 2013-06-03 → 2017-01-04; baseline finish 2013-06-17 → 2017-01-19 |
| 3 | Interview space planners | 2017-06-05 → 2017-01-04 A (-152d) | 2017-06-08 → 2017-01-09 A (-150d) |  | 0% → 100% | 0d → none |  | constraint none → start no earlier than 2017-01-04; resources none → Operations Manager; Office Manager; Vice President [25%]; baseline start 2013-06-03 → 2017-01-04; baseline finish 2013-06-06 → 2017-01-09 |
| 4 | Hire space planner | 2017-06-09 → 2017-01-10 A (-150d) | 2017-06-09 → 2017-01-10 A (-150d) |  | 0% → 100% | 0d → none |  | resources none → Vice President; Administrative Assistant; baseline start 2013-06-07 → 2017-01-10; baseline finish 2013-06-07 → 2017-01-10 |
| 5 | Meeting w/space planner | 2017-06-12 → 2017-01-11 A (-152d) | 2017-06-14 → 2017-01-13 A (-152d) | 3d → 2.5d | 0% → 100% | 0d → none |  | resources none → Vice President; Administrative Assistant; Operations Manager; Space Planner; baseline start 2013-06-10 → 2017-01-11; baseline finish 2013-06-12 → 2017-01-13 |
| 6 | Finalize space plan | 2017-06-15 → 2017-01-16 A (-150d) | 2017-06-19 → 2017-01-19 A (-151d) | 3d → 4d | 0% → 100% | 0d → none |  | resources none → Space Planner; baseline start 2013-06-13 → 2017-01-16; baseline finish 2013-06-17 → 2017-01-19 |
| 7 | **Furniture selection** | 2017-06-15 → 2017-01-16 A (-150d) | 2017-07-04 → 2017-03-13 (-113d) | 13d → 40d | 0% → 83% | 10d → 0d |  | baseline start 2013-06-13 → 2017-01-16; baseline finish 2013-07-02 → 2017-03-13 |
| 8 | Preview furniture selections | 2017-06-15 → 2017-01-16 A (-150d) | 2017-06-19 → 2017-01-18 A (-152d) |  | 0% → 100% | 10d → none | 5 → 6FS-2d | resources none → Office Manager; Operations Manager; Administrative Assistant; baseline start 2013-06-13 → 2017-01-16; baseline finish 2013-06-17 → 2017-01-18 |
| 9 | Select new furniture | 2017-06-19 → 2017-01-18 A (-152d) | 2017-06-21 → 2017-01-20 A (-152d) | 2.5d → 2d | 0% → 100% | 10d → none |  | resources none → Office Manager [75%]; Operations Manager; baseline start 2013-06-17 → 2017-01-18; baseline finish 2013-06-19 → 2017-01-20 |
| 10 | Order new furniture | 2017-06-22 → 2017-01-20 A (-153d) | 2017-06-22 → 2017-01-23 (-150d) | 0.5d → 1.38d | 0% → 27% | 10d → 26.62d |  | resources none → Administrative Assistant; baseline start 2013-06-20 → 2017-01-20; baseline finish 2013-06-20 → 2017-01-23 |
| 11 | Furniture delivered | 2017-07-04 → 2017-03-13 (-113d) | 2017-07-04 → 2017-03-13 (-113d) |  |  | 10d → 0d |  | constraint start no earlier than 2017-07-04 → start no earlier than 2017-03-13; baseline start 2013-07-02 → 2017-03-13; baseline finish 2013-07-02 → 2017-03-13 |
| 12 | **Remodel workspace** | 2017-06-20 → 2017-01-19 A (-152d) | 2017-07-10 → 2017-02-07 (-153d) | 15d → 13.5d | 0% → 22% | 0d → 23.5d |  | baseline start 2013-06-18 → 2017-01-19; baseline finish 2013-07-08 → 2017-02-07 |
| 13 | Hire contractor | 2017-06-20 → 2017-01-19 A (-152d) | 2017-06-26 → 2017-01-24 (-153d) | 5d → 3.5d | 0% → 86% | 0d → 1d | Space plan complete → none | resources none → Vice President; Operations Manager; baseline start 2013-06-18 → 2017-01-19; baseline finish 2013-06-24 → 2017-01-24 |
| 14 | Remodel workspace | 2017-06-27 → 2017-01-24 (-154d) | 2017-07-10 → 2017-02-07 (-153d) |  |  | 0d → 18.5d |  | resources none → Contractor [200%]; Electrician; baseline start 2013-06-25 → 2017-01-24; baseline finish 2013-07-08 → 2017-02-07 |
| 15 | Remodel complete | 2017-07-10 → 2017-02-07 (-153d) | 2017-07-10 → 2017-02-07 (-153d) |  |  | 5d → 23.5d |  | baseline start 2013-07-08 → 2017-02-07; baseline finish 2013-07-08 → 2017-02-07 |
| 16 | **New workspace** | 2017-06-20 → 2017-01-19 A (-152d) | 2017-07-17 → 2017-02-14 (-153d) | 20d → 18.5d | 0% → 23% | 0d → 18.5d |  | baseline start 2013-06-18 → 2017-01-19; baseline finish 2013-07-15 → 2017-02-14 |
| 17 | Hire mover | 2017-06-20 → 2017-01-19 A (-152d) | 2017-06-23 → 2017-01-24 (-150d) |  | 0% → 50% | 8d → 0.5d |  | resources none → Supervisor; baseline start 2013-06-18 → 2017-01-19; baseline finish 2013-06-21 → 2017-01-24 |
| 18 | Pack workspace | 2017-06-27 → 2017-01-25 A (-153d) | 2017-06-27 → 2017-01-25 (-153d) |  | 0% → 50% | 7d → 25d |  | resources none → Administrative Assistant; Supervisor; baseline start 2013-06-25 → 2017-01-25; baseline finish 2013-06-25 → 2017-01-25 |
| 19 | Move Equipment | 2017-06-27 → 2017-01-25 A (-153d) | 2017-06-27 → 2017-01-26 (-152d) | 0.5d → 1d | 0% → 50% | 7d → 24.5d |  | resources none → Mover; Operations Manager; baseline start 2013-06-25 → 2017-01-25; baseline finish 2013-06-25 → 2017-01-26 |
| 20 | Remove existing furniture | 2017-07-07 → 2017-01-26 (-162d) | 2017-07-10 → 2017-01-30 (-161d) |  |  | 0d → 24.5d |  | constraint as late as possible → none; resources none → Mover; baseline start 2013-07-05 → 2017-01-26; baseline finish 2013-07-08 → 2017-01-30 |
| 21 | Assemble new furniture | 2017-07-11 → 2017-02-08 (-153d) | 2017-07-12 → 2017-02-09 (-153d) |  |  | 0d → 18d |  | constraint none → finish no earlier than 2017-02-09; resources none → Supervisor; Space Planner; baseline start 2013-07-09 → 2017-02-08; baseline finish 2013-07-10 → 2017-02-09 |
| 22 | Return equipment | 2017-07-12 → 2017-02-09 (-153d) | 2017-07-12 → 2017-02-09 (-153d) |  |  | 0d → 18d |  | constraint none → finish no earlier than 2017-02-09; resources none → Mover; Operations Manager; baseline start 2013-07-10 → 2017-02-09; baseline finish 2013-07-10 → 2017-02-09 |
| 23 | Unpack workspace | 2017-07-13 → 2017-02-10 (-153d) | 2017-07-13 → 2017-02-10 (-153d) |  |  | 0d → 18d |  | resources none → Mover; Administrative Assistant; baseline start 2013-07-11 → 2017-02-10; baseline finish 2013-07-11 → 2017-02-10 |
| 24 | Workspace final clean | 2017-07-14 → 2017-02-13 (-151d) | 2017-07-17 → 2017-02-14 (-153d) | 2d → 1.5d |  | 0d → 18d |  | resources none → Maintenance [50%]; Mover [50%]; baseline start 2013-07-12 → 2017-02-13; baseline finish 2013-07-15 → 2017-02-14 |
| 25 | Workspace remodel complete | 2017-07-17 → 2017-02-14 (-153d) | 2017-07-17 → 2017-02-14 (-153d) |  |  | 0d → 18.5d |  | constraint finish no later than 2017-07-20 → start no earlier than 2017-02-13; baseline start 2013-07-15 → 2017-02-14; baseline finish 2013-07-15 → 2017-02-14 |

## Version 7 (data date 2016-06-22, saved 2016-07-09, file 3eva.mpp)

Last finish 2017-03-13 → 2017-01-02 (-70d). Complete tasks 6 → 8.

Changed:

| ID | Task | Start | Finish | Duration | Complete | Total float | Predecessors | Other |
| --- | --- | --- | --- | --- | --- | --- | --- | --- |
| 1 | **Office Workspace Remodel** | 2017-01-04 A → 2016-06-29 A (-189d) | 2017-03-13 → 2017-01-02 (-70d) | 48d → 133d | 51% → 76% |  |  | baseline start 2017-01-04 → 2016-06-29; baseline finish 2017-03-13 → 2017-01-02 |
| 2 | **Space planning** | 2017-01-04 A → 2016-06-29 A (-189d) | 2017-01-19 A → 2016-07-14 (-189d) |  | 100% → 91% | none → 121d |  | baseline start 2017-01-04 → 2016-06-29; baseline finish 2017-01-19 → 2016-07-14 |
| 3 | Interview space planners | 2017-01-04 A → 2016-06-29 A (-189d) | 2017-01-09 A → 2016-07-04 A (-189d) |  |  |  |  | constraint start no earlier than 2017-01-04 → start no earlier than 2016-06-29; baseline start 2017-01-04 → 2016-06-29; baseline finish 2017-01-09 → 2016-07-04 |
| 4 | Hire space planner | 2017-01-10 A → 2016-07-05 A (-189d) | 2017-01-10 A → 2016-07-05 A (-189d) |  |  |  |  | baseline start 2017-01-10 → 2016-07-05; baseline finish 2017-01-10 → 2016-07-05 |
| 5 | Meeting w/space planner | 2017-01-11 A → 2016-07-06 A (-189d) | 2017-01-13 A → 2016-07-08 A (-189d) |  |  |  |  | baseline start 2017-01-11 → 2016-07-06; baseline finish 2017-01-13 → 2016-07-08 |
| 6 | Finalize space plan | 2017-01-16 A → 2016-07-11 A (-189d) | 2017-01-19 A → 2016-07-14 (-189d) |  | 100% → 75% | none → 121d |  | baseline start 2017-01-16 → 2016-07-11; baseline finish 2017-01-19 → 2016-07-14 |
| 7 | **Furniture selection** | 2017-01-16 A → 2016-07-11 A (-189d) | 2017-03-13 → 2016-07-28 (-228d) | 40d → 13.38d | 83% → 94% | 0d → 111.62d |  | baseline start 2017-01-16 → 2016-07-11; baseline finish 2017-03-13 → 2016-07-28 |
| 8 | Preview furniture selections | 2017-01-16 A → 2016-07-11 A (-189d) | 2017-01-18 A → 2016-07-13 A (-189d) |  |  |  | 6FS-2d → 5 | baseline start 2017-01-16 → 2016-07-11; baseline finish 2017-01-18 → 2016-07-13 |
| 9 | Select new furniture | 2017-01-18 A → 2016-07-13 A (-189d) | 2017-01-20 A → 2016-07-15 A (-189d) |  |  |  |  | baseline start 2017-01-18 → 2016-07-13; baseline finish 2017-01-20 → 2016-07-15 |
| 10 | Order new furniture | 2017-01-20 A → 2016-07-15 A (-189d) | 2017-01-23 → 2016-07-18 (-189d) |  | 27% → 73% | 26.62d → 111.62d |  | baseline start 2017-01-20 → 2016-07-15; baseline finish 2017-01-23 → 2016-07-18 |
| 11 | Furniture delivered | 2017-03-13 → 2016-07-28 (-228d) | 2017-03-13 → 2016-07-28 (-228d) |  |  | 0d → 111.62d |  | constraint start no earlier than 2017-03-13 → none; baseline start 2017-03-13 → 2016-07-28; baseline finish 2017-03-13 → 2016-07-28 |
| 12 | **Remodel workspace** | 2017-01-19 A → 2016-07-14 A (-189d) | 2017-02-07 → 2016-08-02 (-189d) |  | 22% → 77% | 23.5d → 108.5d |  | baseline start 2017-01-19 → 2016-07-14; baseline finish 2017-02-07 → 2016-08-02 |
| 13 | Hire contractor | 2017-01-19 A → 2016-07-14 A (-189d) | 2017-01-24 → 2016-07-20 (-188d) | 3.5d → 4.25d | 86% → 82% | 1d → 6.75d |  | baseline start 2017-01-19 → 2016-07-14; baseline finish 2017-01-24 → 2016-07-20 |
| 14 | Remodel workspace | 2017-01-24 → 2016-07-19 A (-189d) | 2017-02-07 → 2016-08-02 (-189d) |  | 0% → 75% | 18.5d → 103.5d |  | baseline start 2017-01-24 → 2016-07-19; baseline finish 2017-02-07 → 2016-08-02 |
| 15 | Remodel complete | 2017-02-07 → 2016-08-02 (-189d) | 2017-02-07 → 2016-08-02 (-189d) |  |  | 23.5d → 108.5d |  | baseline start 2017-02-07 → 2016-08-02; baseline finish 2017-02-07 → 2016-08-02 |
| 16 | **New workspace** | 2017-01-19 A → 2016-07-14 A (-189d) | 2017-02-14 → 2016-12-29 (-47d) | 18.5d → 120.5d | 23% → 54% | 18.5d → 1.5d |  | baseline start 2017-01-19 → 2016-07-14; baseline finish 2017-02-14 → 2016-12-29 |
| 17 | Hire mover | 2017-01-19 A → 2016-07-14 A (-189d) | 2017-01-24 → 2016-07-19 (-189d) |  | 50% → 75% | 0.5d → 118d |  | baseline start 2017-01-19 → 2016-07-14; baseline finish 2017-01-24 → 2016-07-19 |
| 18 | Pack workspace | 2017-01-25 A → 2016-07-20 A (-189d) | 2017-01-25 → 2016-07-20 A (-189d) |  | 50% → 100% | 25d → none |  | baseline start 2017-01-25 → 2016-07-20; baseline finish 2017-01-25 → 2016-07-20 |
| 19 | Move Equipment | 2017-01-25 A → 2016-07-20 A (-189d) | 2017-01-26 → 2016-07-21 A (-189d) |  | 50% → 100% | 24.5d → none |  | baseline start 2017-01-25 → 2016-07-20; baseline finish 2017-01-26 → 2016-07-21 |
| 20 | Remove existing furniture | 2017-01-26 → 2016-07-21 A (-189d) | 2017-01-30 → 2016-07-25 A (-189d) |  | 0% → 100% | 24.5d → none |  | baseline start 2017-01-26 → 2016-07-21; baseline finish 2017-01-30 → 2016-07-25 |
| 21 | Assemble new furniture | 2017-02-08 → 2016-12-23 (-47d) | 2017-02-09 → 2016-12-26 (-45d) |  |  | 18d → 1d |  | constraint finish no earlier than 2017-02-09 → finish no earlier than 2016-12-26; baseline start 2017-02-08 → 2016-12-23; baseline finish 2017-02-09 → 2016-12-26 |
| 22 | Return equipment | 2017-02-09 → 2016-12-26 (-45d) | 2017-02-09 → 2016-12-26 (-45d) |  |  | 18d → 1d |  | constraint finish no earlier than 2017-02-09 → finish no earlier than 2016-12-26; baseline start 2017-02-09 → 2016-12-26; baseline finish 2017-02-09 → 2016-12-26 |
| 23 | Unpack workspace | 2017-02-10 → 2016-12-27 (-45d) | 2017-02-10 → 2016-12-27 (-45d) |  |  | 18d → 1d |  | baseline start 2017-02-10 → 2016-12-27; baseline finish 2017-02-10 → 2016-12-27 |
| 24 | Workspace final clean | 2017-02-13 → 2016-12-28 (-47d) | 2017-02-14 → 2016-12-29 (-47d) |  |  | 18d → 1d |  | baseline start 2017-02-13 → 2016-12-28; baseline finish 2017-02-14 → 2016-12-29 |
| 25 | Workspace remodel complete | 2017-02-14 → 2017-01-02 (-43d) | 2017-02-14 → 2017-01-02 (-43d) |  |  | 18.5d → 0d |  | constraint start no earlier than 2017-02-13 → start no earlier than 2017-01-02; baseline start 2017-02-14 → 2017-01-02; baseline finish 2017-02-14 → 2017-01-02 |

## Version 8 (saved 2016-07-11, file 2organizer.mpp)

Last finish 2017-01-02 → 2017-07-20 (+199d). Complete tasks 8 → 5.

Added:

| ID | Task | Duration | Start | Finish | Predecessors |
| --- | --- | --- | --- | --- | --- |
| 7 | Space plan complete | 0d | 2017-01-20 A | 2017-01-20 A | 6 |

Changed:

| ID | Task | Start | Finish | Duration | Complete | Total float | Predecessors | Other |
| --- | --- | --- | --- | --- | --- | --- | --- | --- |
| 1 | **Office Workspace Remodel** | 2016-06-29 A → 2017-01-04 A (+189d) | 2017-01-02 → 2017-07-20 (+199d) | 133d → 141d | 76% → 42% |  |  | baseline start 2016-06-29 → 2008-01-02; baseline finish 2017-01-02 → 2008-03-10 |
| 2 | **Space planning** | 2016-06-29 A → 2017-01-04 A (+189d) | 2016-07-14 → 2017-01-20 (+190d) |  |  | 121d → 129d |  | baseline start 2016-06-29 → 2008-01-02; baseline finish 2016-07-14 → 2008-01-16 |
| 3 | Interview space planners | 2016-06-29 A → 2017-01-04 A (+189d) | 2016-07-04 A → 2017-01-09 A (+189d) |  |  |  |  | constraint start no earlier than 2016-06-29 → start no earlier than 2017-01-04; baseline start 2016-06-29 → 2008-01-02; baseline finish 2016-07-04 → 2008-01-07 |
| 4 | Hire space planner | 2016-07-05 A → 2017-01-10 A (+189d) | 2016-07-05 A → 2017-01-10 A (+189d) |  |  |  |  | baseline start 2016-07-05 → 2008-01-08; baseline finish 2016-07-05 → 2008-01-08 |
| 5 | Meeting w/space planner | 2016-07-06 A → 2017-01-11 A (+189d) | 2016-07-08 A → 2017-01-13 A (+189d) |  |  |  |  | baseline start 2016-07-06 → 2008-01-09; baseline finish 2016-07-08 → 2008-01-11 |
| 6 | Finalize space plan | 2016-07-11 A → 2017-01-16 A (+189d) | 2016-07-14 → 2017-01-19 (+189d) |  |  | 121d → 129d |  | baseline start 2016-07-11 → 2008-01-14; baseline finish 2016-07-14 → 2008-01-16 |
| 8 | **Furniture selection** | 2016-07-11 A → 2017-01-16 A (+189d) | 2016-07-28 → 2017-03-13 (+228d) | 13.38d → 40d | 94% → 85% | 111.62d → 93d |  | baseline start 2016-07-11 → 2008-01-14; baseline finish 2016-07-28 → 2008-03-10 |
| 9 | Preview furniture selections | 2016-07-11 A → 2017-01-16 A (+189d) | 2016-07-13 A → 2017-01-18 A (+189d) |  |  |  |  | baseline start 2016-07-11 → 2008-01-14; baseline finish 2016-07-13 → 2008-01-16 |
| 10 | Select new furniture | 2016-07-13 A → 2017-01-18 A (+189d) | 2016-07-15 A → 2017-01-20 (+189d) |  | 100% → 75% | none → 0.38d |  | baseline start 2016-07-13 → 2008-01-16; baseline finish 2016-07-15 → 2008-01-18 |
| 11 | Order new furniture | 2016-07-15 A → 2017-01-20 A (+189d) | 2016-07-18 → 2017-01-23 (+189d) | 1.38d → 0.62d | 73% → 60% | 111.62d → 120.38d |  | baseline start 2016-07-15 → 2008-01-18; baseline finish 2016-07-18 → 2008-01-18 |
| 12 | Furniture delivered | 2016-07-28 → 2017-03-13 (+228d) | 2016-07-28 → 2017-03-13 (+228d) |  |  | 111.62d → 93d |  | constraint none → start no earlier than 2017-03-13; baseline start 2016-07-28 → 2008-03-10; baseline finish 2016-07-28 → 2008-03-10 |
| 13 | **Remodel workspace** | 2016-07-14 A → 2017-01-19 A (+189d) | 2016-08-02 → 2017-02-07 (+189d) | 13.5d → 14d | 77% → 21% | 108.5d → 116d |  | baseline start 2016-07-14 → 2008-01-17; baseline finish 2016-08-02 → 2008-02-05 |
| 14 | Hire contractor | 2016-07-14 A → 2017-01-19 A (+189d) | 2016-07-20 → 2017-01-24 (+188d) | 4.25d → 4d | 82% → 75% | 6.75d → 112d | none → 7 | baseline start 2016-07-14 → 2008-01-17; baseline finish 2016-07-20 → 2008-01-22 |
| 15 | Remodel workspace | 2016-07-19 A → 2017-01-25 (+190d) | 2016-08-02 → 2017-02-07 (+189d) |  | 75% → 0% | 103.5d → 112d |  | baseline start 2016-07-19 → 2008-01-23; baseline finish 2016-08-02 → 2008-02-05 |
| 16 | Remodel complete | 2016-08-02 → 2017-02-07 (+189d) | 2016-08-02 → 2017-02-07 (+189d) |  |  | 108.5d → 116d |  | baseline start 2016-08-02 → 2008-02-05; baseline finish 2016-08-02 → 2008-02-05 |
| 17 | **New workspace** | 2016-07-14 A → 2017-01-19 (+189d) | 2016-12-29 → 2017-07-18 (+201d) | 120.5d → 129d | 54% → 0% | 1.5d → 1d |  | baseline start 2016-07-14 → 2008-01-17; baseline finish 2016-12-29 → 2008-02-11 |
| 18 | Hire mover | 2016-07-14 A → 2017-01-19 (+189d) | 2016-07-19 → 2017-01-24 (+189d) |  | 75% → 0% | 118d → 119d |  | baseline start 2016-07-14 → 2008-01-17; baseline finish 2016-07-19 → 2008-01-22 |
| 19 | Pack workspace | 2016-07-20 A → 2017-01-25 (+189d) | 2016-07-20 A → 2017-01-25 (+189d) |  | 100% → 0% | none → 119d |  | baseline start 2016-07-20 → 2008-01-23; baseline finish 2016-07-20 → 2008-01-23 |
| 20 | Move Equipment | 2016-07-20 A → 2017-01-25 (+189d) | 2016-07-21 A → 2017-01-25 (+188d) | 1d → 0.5d | 100% → 0% | none → 119d |  | baseline start 2016-07-20 → 2008-01-23; baseline finish 2016-07-21 → 2008-01-23 |
| 21 | Remove existing furniture | 2016-07-21 A → 2017-01-26 (+189d) | 2016-07-25 A → 2017-01-27 (+186d) |  | 100% → 0% | none → 119d |  | baseline start 2016-07-21 → 2008-01-24; baseline finish 2016-07-25 → 2008-01-25 |
| 22 | Assemble new furniture | 2016-12-23 → 2017-07-13 (+202d) | 2016-12-26 → 2017-07-14 (+200d) |  |  |  |  | constraint finish no earlier than 2016-12-26 → finish no earlier than 2017-07-14; baseline start 2016-12-23 → 2008-02-06; baseline finish 2016-12-26 → 2008-02-07 |
| 23 | Return equipment | 2016-12-26 → 2017-07-14 (+200d) | 2016-12-26 → 2017-07-14 (+200d) |  |  |  |  | constraint finish no earlier than 2016-12-26 → finish no earlier than 2017-07-14; baseline start 2016-12-26 → 2008-02-07; baseline finish 2016-12-26 → 2008-02-07 |
| 24 | Unpack workspace | 2016-12-27 → 2017-07-17 (+202d) | 2016-12-27 → 2017-07-17 (+202d) |  |  |  |  | baseline start 2016-12-27 → 2008-02-08; baseline finish 2016-12-27 → 2008-02-08 |
| 25 | Workspace final clean | 2016-12-28 → 2017-07-18 (+202d) | 2016-12-29 → 2017-07-18 (+201d) | 1.5d → 1d |  |  |  | baseline start 2016-12-28 → 2008-02-11; baseline finish 2016-12-29 → 2008-02-11 |
| 26 | Workspace remodel complete | 2017-01-02 → 2017-07-20 (+199d) | 2017-01-02 → 2017-07-20 (+199d) |  |  |  |  | constraint start no earlier than 2017-01-02 → start no earlier than 2017-07-20; baseline start 2017-01-02 → 2008-02-11; baseline finish 2017-01-02 → 2008-02-11 |

## Version 9 (data date 2017-01-31, saved 2016-07-15, file 5remodel.mpp)

Last finish 2017-07-20 → 2017-02-10 (-160d). Complete tasks 5 → 1.

Changed:

| ID | Task | Start | Finish | Duration | Complete | Total float | Predecessors | Other |
| --- | --- | --- | --- | --- | --- | --- | --- | --- |
| 1 | **Office Workspace Remodel** |  | 2017-07-20 → 2017-02-10 (-160d) | 141d → 27.5d | 42% → 0% |  |  | baseline start 2008-01-02 → 2017-01-04; baseline finish 2008-03-10 → 2017-02-10 |
| 2 | **Space planning** |  | 2017-01-20 → 2017-01-19 (-1d) | 12d → 11d | 91% → 0% | 129d → 16.5d |  | baseline start 2008-01-02 → 2017-01-04; baseline finish 2008-01-16 → 2017-01-19 |
| 3 | Interview space planners | 2017-01-04 A → 2017-01-04 | 2017-01-09 A → 2017-01-09 |  | 100% → 0% | none → 7d |  | constraint start no earlier than 2017-01-04 → none; baseline start 2008-01-02 → 2017-01-04; baseline finish 2008-01-07 → 2017-01-09 |
| 4 | Hire space planner | 2017-01-10 A → 2017-01-10 | 2017-01-10 A → 2017-01-10 |  | 100% → 0% | none → 7d |  | baseline start 2008-01-08 → 2017-01-10; baseline finish 2008-01-08 → 2017-01-10 |
| 5 | Meeting w/space planner | 2017-01-11 A → 2017-01-11 | 2017-01-13 A → 2017-01-13 | 2.5d → 3d | 100% → 0% | none → 7d |  | baseline start 2008-01-09 → 2017-01-11; baseline finish 2008-01-11 → 2017-01-13 |
| 6 | Finalize space plan | 2017-01-16 A → 2017-01-16 | 2017-01-19 → 2017-01-18 (-1d) | 4d → 3d | 75% → 0% | 129d → 16.5d |  | baseline start 2008-01-14 → 2017-01-16; baseline finish 2008-01-16 → 2017-01-18 |
| 7 | Space plan complete | 2017-01-20 A → 2017-01-19 A (-1d) | 2017-01-20 A → 2017-01-19 A (-1d) |  |  |  |  | baseline start 2008-01-16 → 2017-01-19; baseline finish 2008-01-16 → 2017-01-19 |
| 8 | **Furniture selection** | 2017-01-16 A → 2017-01-16 | 2017-03-13 → 2017-02-02 (-39d) | 40d → 13d | 85% → 0% | 93d → 6.5d |  | baseline start 2008-01-14 → 2017-01-16; baseline finish 2008-03-10 → 2017-02-02 |
| 9 | Preview furniture selections | 2017-01-16 A → 2017-01-16 | 2017-01-18 A → 2017-01-18 |  | 100% → 0% | none → 7d |  | baseline start 2008-01-14 → 2017-01-16; baseline finish 2008-01-16 → 2017-01-18 |
| 10 | Select new furniture | 2017-01-18 A → 2017-01-18 |  |  | 75% → 0% | 0.38d → 7d |  | baseline start 2008-01-16 → 2017-01-18; baseline finish 2008-01-18 → 2017-01-20 |
| 11 | Order new furniture | 2017-01-20 A → 2017-01-20 | 2017-01-23 → 2017-01-20 (-3d) | 0.62d → 0.5d | 60% → 0% | 120.38d → 7d |  | baseline start 2008-01-18 → 2017-01-20; baseline finish 2008-01-18 → 2017-01-20 |
| 12 | Furniture delivered | 2017-03-13 → 2017-02-02 (-39d) | 2017-03-13 → 2017-02-02 (-39d) |  |  | 93d → 6.5d |  | constraint start no earlier than 2017-03-13 → start no earlier than 2017-02-02; baseline start 2008-03-10 → 2017-02-02; baseline finish 2008-03-10 → 2017-02-02 |
| 13 | **Remodel workspace** | 2017-01-19 A → 2017-01-19 | 2017-02-07 → 2017-02-06 (-1d) | 14d → 13d | 21% → 0% | 116d → 0d |  | baseline start 2008-01-17 → 2017-01-19; baseline finish 2008-02-05 → 2017-02-06 |
| 14 | Hire contractor | 2017-01-19 A → 2017-01-19 |  |  | 75% → 0% | 112d → 0d |  | baseline start 2008-01-17 → 2017-01-19; baseline finish 2008-01-22 → 2017-01-24 |
| 15 | Remodel workspace |  | 2017-02-07 → 2017-02-06 (-1d) | 2w → 9d |  | 112d → 0d |  | baseline start 2008-01-23 → 2017-01-25; baseline finish 2008-02-05 → 2017-02-06 |
| 16 | Remodel complete | 2017-02-07 → 2017-02-06 (-1d) | 2017-02-07 → 2017-02-06 (-1d) |  |  | 116d → 3.5d |  | baseline start 2008-02-05 → 2017-02-06; baseline finish 2008-02-05 → 2017-02-06 |
| 17 | **New workspace** |  | 2017-07-18 → 2017-02-10 (-158d) | 129d → 16.5d |  | 1d → 0d |  | baseline start 2008-01-17 → 2017-01-19; baseline finish 2008-02-11 → 2017-02-10 |
| 18 | Hire mover |  |  |  |  | 119d → 6d |  | baseline start 2008-01-17 → 2017-01-19; baseline finish 2008-01-22 → 2017-01-24 |
| 19 | Pack workspace |  |  |  |  | 119d → 6d |  | baseline start 2008-01-23 → 2017-01-25; baseline finish 2008-01-23 → 2017-01-25 |
| 20 | Move Equipment |  |  |  |  | 119d → 6d |  | baseline start 2008-01-23 → 2017-01-25; baseline finish 2008-01-23 → 2017-01-25 |
| 21 | Remove existing furniture | 2017-01-26 → 2017-02-03 (+8d) | 2017-01-27 → 2017-02-06 (+10d) |  |  | 119d → 0d |  | constraint none → as late as possible; baseline start 2008-01-24 → 2017-02-03; baseline finish 2008-01-25 → 2017-02-06 |
| 22 | Assemble new furniture | 2017-07-13 → 2017-02-07 (-156d) | 2017-07-14 → 2017-02-08 (-156d) |  |  | 1d → 0d |  | constraint finish no earlier than 2017-07-14 → none; baseline start 2008-02-06 → 2017-02-07; baseline finish 2008-02-07 → 2017-02-08 |
| 23 | Return equipment | 2017-07-14 → 2017-02-08 (-156d) | 2017-07-14 → 2017-02-08 (-156d) |  |  | 1d → 0d |  | constraint finish no earlier than 2017-07-14 → none; baseline start 2008-02-07 → 2017-02-08; baseline finish 2008-02-07 → 2017-02-08 |
| 24 | Unpack workspace | 2017-07-17 → 2017-02-09 (-158d) | 2017-07-17 → 2017-02-09 (-158d) |  |  | 1d → 0d |  | baseline start 2008-02-08 → 2017-02-09; baseline finish 2008-02-08 → 2017-02-09 |
| 25 | Workspace final clean | 2017-07-18 → 2017-02-09 (-159d) | 2017-07-18 → 2017-02-10 (-158d) |  |  | 1d → 0d | 24 → 24FS-0.5d | baseline start 2008-02-11 → 2017-02-09; baseline finish 2008-02-11 → 2017-02-10 |
| 26 | Workspace remodel complete | 2017-07-20 → 2017-02-10 (-160d) | 2017-07-20 → 2017-02-10 (-160d) |  |  |  |  | constraint start no earlier than 2017-07-20 → finish no later than 2017-02-15; baseline start 2008-02-11 → 2017-02-10; baseline finish 2008-02-11 → 2017-02-10 |
