# 2017 Shareholder Meeting

How a schedule from MS Project changed from version to version. A marks actual dates.

## Version 1 (saved 2016-07-02, file 2meeting-2017.mpp)

| ID | WBS | Task | Duration | Start | Finish | Predecessors | Total float | Constraint |
| --- | --- | --- | --- | --- | --- | --- | --- | --- |
| 1 | 1 | **Shareholders Meeting** | 32d | 2017-06-05 | 2017-07-18 |  | 0d |  |
| 2 | 1.1 | **Plan meeting** | 13.5d | 2017-06-05 | 2017-06-22 |  | 1.12d |  |
| 3 | 1.1.1 | **Preliminary planning** | 13.5d | 2017-06-05 | 2017-06-22 |  | 1.12d |  |
| 4 |  | Schedule conference date | 2d | 2017-06-05 | 2017-06-06 |  | 1.12d |  |
| 5 |  | Book conference center | 2d | 2017-06-07 | 2017-06-08 | 4 | 1.12d |  |
| 6 |  | Book keynote speaker | 10d | 2017-06-08 | 2017-06-22 | 5FS-0.5d | 1.12d |  |
| 7 |  | Preliminary planning complete | 0d | 2017-06-22 | 2017-06-22 | 6 | 1.12d |  |
| 8 | 1.2 | **Notification letter** | 8.88d | 2017-06-22 | 2017-07-05 | 3 | 1.12d |  |
| 9 |  | Order letter stock | 1h | 2017-06-22 | 2017-06-22 |  | 1.12d |  |
| 10 |  | Develop letter | 2d | 2017-06-22 | 2017-06-26 | 9 | 1.12d |  |
| 11 |  | Review letter | 3.25d | 2017-06-26 | 2017-06-29 | 10 | 1.12d |  |
| 12 |  | Approve letter | 1d | 2017-06-29 | 2017-06-30 | 11 | 9.62d |  |
| 13 |  | Print letter | 2.5d | 2017-06-30 | 2017-07-05 | 12 | 9.62d |  |
| 14 |  | Send letter | 0d | 2017-07-05 | 2017-07-05 | 13 | 9.62d |  |
| 15 | 1.3 | **Meeting details** | 11d | 2017-06-29 | 2017-07-14 | 3 | 1.12d |  |
| 16 |  | Plan food with caterer | 4.62d | 2017-06-29 | 2017-07-06 | 11 | 1.12d |  |
| 17 |  | Arrange committee meeting rooms | 0.5d | 2017-06-29 | 2017-06-30 | 16SS | 1.12d |  |
| 18 |  | Arrange necessary equipment | 1.5d | 2017-06-30 | 2017-07-03 | 17 | 1.12d |  |
| 19 |  | Create agenda | 3.5d | 2017-07-03 | 2017-07-07 | 18 | 1.12d |  |
| 20 |  | Print agenda | 5.5d | 2017-07-07 | 2017-07-14 | 19 | 1.12d |  |
| 21 |  | Meeting Details Complete | 0d | 2017-07-14 | 2017-07-14 | 20 | 2.12d |  |
| 22 |  | Meeting occurs! | 1d | 2017-07-18 | 2017-07-18 | 2FS+2d, 16, 17, 18, 20 | 0d | must finish on 2017-07-18 |

## Version 2 (data date 2017-05-27, saved 2016-07-02, file 6share2.mpp)

Last finish 2017-07-18 → 2017-06-15 (-33d). Complete tasks 0 → 1.

Added:

| ID | Task | Duration | Start | Finish |
| --- | --- | --- | --- | --- |
| 4 | Schedule meeting date | 1d | 2017-05-17 | 2017-05-17 |

Removed: 4 Schedule conference date; 21 Meeting Details Complete

Changed:

| ID | Task | Start | Finish | Duration | Complete | Total float | Predecessors | Other |
| --- | --- | --- | --- | --- | --- | --- | --- | --- |
| 1 | **Shareholders Meeting** | 2017-06-05 → 2017-05-17 A (-19d) | 2017-07-18 → 2017-06-15 (-33d) | 32d → 21.62d |  |  |  | baseline start none → 2013-05-14; baseline finish none → 2013-06-12 |
| 2 | **Plan meeting** | 2017-06-05 → 2017-05-17 A (-19d) | 2017-06-22 → 2017-06-12 (-10d) | 13.5d → 18.62d |  | 1.12d → 0d |  | baseline start none → 2013-05-14; baseline finish none → 2013-06-07 |
| 3 | **Preliminary planning** | 2017-06-05 → 2017-05-17 A (-19d) | 2017-06-22 → 2017-06-02 (-20d) | 13.5d → 12.5d |  | 1.12d → 0d |  | baseline start none → 2013-05-14; baseline finish none → 2013-05-30 |
| 5 | Book conference center | 2017-06-07 → 2017-05-18 (-20d) | 2017-06-08 → 2017-05-19 (-20d) |  |  | 1.12d → 0d | Schedule conference date → 4 | resources Sam Merris → none; baseline start none → 2013-05-15; baseline finish none → 2013-05-16 |
| 6 | Book keynote speaker | 2017-06-08 → 2017-05-19 (-20d) | 2017-06-22 → 2017-06-02 (-20d) |  |  | 1.12d → 0d |  | resources Leslie Mitchell; Terry Johnstone → none; baseline start none → 2013-05-16; baseline finish none → 2013-05-30 |
| 7 | Preliminary planning complete | 2017-06-22 → 2017-06-02 A (-20d) | 2017-06-22 → 2017-06-02 A (-20d) |  | 0% → 100% | 1.12d → none |  | baseline start none → 2013-05-30; baseline finish none → 2013-05-30 |
| 8 | **Notification letter** | 2017-06-22 → 2017-06-02 (-20d) | 2017-07-05 → 2017-06-08 (-27d) | 8.88d → 4.12d |  | 1.12d → 0d |  | baseline start none → 2013-05-30; baseline finish none → 2013-06-05 |
| 9 | Order letter stock | 2017-06-22 → 2017-06-02 (-20d) | 2017-06-22 → 2017-06-02 (-20d) |  |  | 1.12d → 0d |  | resources Sam Merris → none; baseline start none → 2013-05-30; baseline finish none → 2013-05-30 |
| 10 | Develop letter | 2017-06-22 → 2017-06-02 (-20d) | 2017-06-26 → 2017-06-05 (-21d) | 2d → 1d |  | 1.12d → 0d |  | resources Terry Johnstone → none; baseline start none → 2013-05-30; baseline finish none → 2013-05-31 |
| 11 | Review letter | 2017-06-26 → 2017-06-02 (-24d) | 2017-06-29 → 2017-06-05 (-24d) | 3.25d → 1d |  | 1.12d → 0d | 10 → 10SS | resources Leslie Mitchell; Alex Patterson → none; baseline start none → 2013-05-30; baseline finish none → 2013-05-31 |
| 12 | Approve letter | 2017-06-29 → 2017-06-05 (-24d) | 2017-06-30 → 2017-06-06 (-24d) |  |  | 9.62d → 2d |  | resources Pat Kelly → none; baseline start none → 2013-05-31; baseline finish none → 2013-06-03 |
| 13 | Print letter | 2017-06-30 → 2017-06-06 (-24d) | 2017-07-05 → 2017-06-08 (-27d) | 2.5d → 2d |  | 9.62d → 2d |  | resources Sam Merris [50%] → none; baseline start none → 2013-06-03; baseline finish none → 2013-06-05 |
| 14 | Send letter | 2017-07-05 → 2017-06-08 (-27d) | 2017-07-05 → 2017-06-08 (-27d) |  |  | 9.62d → 2d |  | baseline start none → 2013-06-05; baseline finish none → 2013-06-05 |
| 15 | **Meeting details** | 2017-06-29 → 2017-06-05 (-24d) | 2017-07-14 → 2017-06-12 (-32d) | 11d → 5d |  | 1.12d → 0d |  | baseline start none → 2013-05-31; baseline finish none → 2013-06-07 |
| 16 | Plan food with caterer | 2017-06-29 → 2017-06-05 (-24d) | 2017-07-06 → 2017-06-08 (-28d) | 4.62d → 3d |  | 1.12d → 0d |  | resources Terry Johnstone; Leslie Mitchell → none; baseline start none → 2013-05-31; baseline finish none → 2013-06-05 |
| 17 | Arrange committee meeting rooms | 2017-06-29 → 2017-06-05 (-24d) | 2017-06-30 → 2017-06-06 (-24d) |  |  | 1.12d → 0d |  | resources Sam Merris → none; baseline start none → 2013-05-31; baseline finish none → 2013-06-03 |
| 18 | Arrange necessary equipment | 2017-06-30 → 2017-06-06 (-24d) | 2017-07-03 → 2017-06-06 (-27d) | 1.5d → 0.5d |  | 1.12d → 0d |  | resources Sam Merris → none; baseline start none → 2013-06-03; baseline finish none → 2013-06-03 |
| 19 | Create agenda | 2017-07-03 → 2017-06-06 (-27d) | 2017-07-07 → 2017-06-09 (-28d) | 3.5d → 3d |  | 1.12d → 0d |  | resources Sam Merris [50%] → none; baseline start none → 2013-06-03; baseline finish none → 2013-06-06 |
| 20 | Print agenda | 2017-07-07 → 2017-06-09 (-28d) | 2017-07-14 → 2017-06-12 (-32d) | 5.5d → 1d |  | 1.12d → 0d |  | resources Sam Merris → none; baseline start none → 2013-06-06; baseline finish none → 2013-06-07 |
| 21 | Meeting occurs! | 2017-07-18 → 2017-06-14 (-34d) | 2017-07-18 → 2017-06-15 (-33d) |  |  |  |  | constraint must finish on 2017-07-18 → none; baseline start none → 2013-06-11; baseline finish none → 2013-06-12 |

## Version 3 (data date 2017-07-31, saved 2016-07-15, file 5shareholder.mpp)

Last finish 2017-06-15 → 2017-07-31 (+46d).

Changed:

| ID | Task | Start | Finish | Duration | Total float | Other |
| --- | --- | --- | --- | --- | --- | --- |
| 1 | **Shareholders Meeting** | 2017-05-17 A → 2017-06-05 A (+19d) | 2017-06-15 → 2017-07-31 (+46d) | 21.62d → 39.62d |  | baseline start 2013-05-14 → 2017-06-05; baseline finish 2013-06-12 → 2017-07-31 |
| 2 | **Plan meeting** | 2017-05-17 A → 2017-06-05 A (+19d) | 2017-06-12 → 2017-07-26 (+44d) | 18.62d → 36.62d |  | baseline start 2013-05-14 → 2017-06-05; baseline finish 2013-06-07 → 2017-07-26 |
| 3 | **Preliminary planning** | 2017-05-17 A → 2017-06-05 A (+19d) | 2017-06-02 → 2017-07-07 (+35d) | 12.5d → 24d |  | baseline start 2013-05-14 → 2017-06-05; baseline finish 2013-05-30 → 2017-07-07 |
| 4 | Schedule meeting date | 2017-05-17 → 2017-06-05 (+19d) | 2017-05-17 → 2017-06-06 (+20d) |  |  | resources none → vice president; office manager; baseline start 2013-05-14 → 2017-06-05; baseline finish 2013-05-14 → 2017-06-06 |
| 5 | Book conference center | 2017-05-18 → 2017-06-07 (+20d) | 2017-05-19 → 2017-06-12 (+24d) |  |  | resources none → intern; baseline start 2013-05-15 → 2017-06-07; baseline finish 2013-05-16 → 2017-06-12 |
| 6 | Book keynote speaker | 2017-05-19 → 2017-06-12 (+24d) | 2017-06-02 → 2017-07-07 (+35d) |  |  | resources none → office manager; administrative assistant; baseline start 2013-05-16 → 2017-06-12; baseline finish 2013-05-30 → 2017-07-07 |
| 7 | Preliminary planning complete | 2017-06-02 A → 2017-07-07 A (+35d) | 2017-06-02 A → 2017-07-07 A (+35d) |  |  | baseline start 2013-05-30 → 2017-07-07; baseline finish 2013-05-30 → 2017-07-07 |
| 8 | **Notification letter** | 2017-06-02 → 2017-07-10 (+38d) | 2017-06-08 → 2017-07-20 (+42d) | 4.12d → 7.62d |  | baseline start 2013-05-30 → 2017-07-10; baseline finish 2013-06-05 → 2017-07-20 |
| 9 | Order letter stock | 2017-06-02 → 2017-07-10 (+38d) | 2017-06-02 → 2017-07-10 (+38d) |  |  | resources none → intern; baseline start 2013-05-30 → 2017-07-10; baseline finish 2013-05-30 → 2017-07-10 |
| 10 | Develop letter | 2017-06-02 → 2017-07-10 (+38d) | 2017-06-05 → 2017-07-12 (+37d) |  |  | resources none → administrative assistant; baseline start 2013-05-30 → 2017-07-10; baseline finish 2013-05-31 → 2017-07-12 |
| 11 | Review letter | 2017-06-02 → 2017-07-10 (+38d) | 2017-06-05 → 2017-07-12 (+37d) |  |  | resources none → office manager; operations manager; baseline start 2013-05-30 → 2017-07-10; baseline finish 2013-05-31 → 2017-07-12 |
| 12 | Approve letter | 2017-06-05 → 2017-07-12 (+37d) | 2017-06-06 → 2017-07-14 (+38d) |  | 2d → 4d | resources none → vice president; baseline start 2013-05-31 → 2017-07-12; baseline finish 2013-06-03 → 2017-07-14 |
| 13 | Print letter | 2017-06-06 → 2017-07-14 (+38d) | 2017-06-08 → 2017-07-20 (+42d) |  | 2d → 4d | resources none → intern [50%]; baseline start 2013-06-03 → 2017-07-14; baseline finish 2013-06-05 → 2017-07-20 |
| 14 | Send letter | 2017-06-08 → 2017-07-20 (+42d) | 2017-06-08 → 2017-07-20 (+42d) |  | 2d → 4d | baseline start 2013-06-05 → 2017-07-20; baseline finish 2013-06-05 → 2017-07-20 |
| 15 | **Meeting details** | 2017-06-05 → 2017-07-12 (+37d) | 2017-06-12 → 2017-07-26 (+44d) | 5d → 10d |  | baseline start 2013-05-31 → 2017-07-12; baseline finish 2013-06-07 → 2017-07-26 |
| 16 | Plan food with caterer | 2017-06-05 → 2017-07-12 (+37d) | 2017-06-08 → 2017-07-20 (+42d) |  |  | resources none → administrative assistant; office manager; baseline start 2013-05-31 → 2017-07-12; baseline finish 2013-06-05 → 2017-07-20 |
| 17 | Arrange committee meeting rooms | 2017-06-05 → 2017-07-12 (+37d) | 2017-06-06 → 2017-07-13 (+37d) |  |  | resources none → intern; baseline start 2013-05-31 → 2017-07-12; baseline finish 2013-06-03 → 2017-07-13 |
| 18 | Arrange necessary equipment | 2017-06-06 → 2017-07-13 (+37d) | 2017-06-06 → 2017-07-14 (+38d) |  |  | resources none → intern; baseline start 2013-06-03 → 2017-07-13; baseline finish 2013-06-03 → 2017-07-14 |
| 19 | Create agenda | 2017-06-06 → 2017-07-14 (+38d) | 2017-06-09 → 2017-07-24 (+45d) |  |  | resources none → intern [50%]; baseline start 2013-06-03 → 2017-07-14; baseline finish 2013-06-06 → 2017-07-24 |
| 20 | Print agenda | 2017-06-09 → 2017-07-24 (+45d) | 2017-06-12 → 2017-07-26 (+44d) |  |  | resources none → intern; baseline start 2013-06-06 → 2017-07-24; baseline finish 2013-06-07 → 2017-07-26 |
| 21 | Meeting occurs! | 2017-06-14 → 2017-07-28 (+44d) | 2017-06-15 → 2017-07-31 (+46d) |  |  | baseline start 2013-06-11 → 2017-07-28; baseline finish 2013-06-12 → 2017-07-31 |
